# Издание номера журнала

Schedule from MS Project, 2002-01-10 to 2002-04-17, status date 2002-02-10, costs in $.
MS Project 2002
Заменяем ресурсы.

## Calendars

- Standard: Mon-Thu 09:00-12:00, 13:00-18:00; Fri 08:00-12:00, 13:00-17:00; Sat-Sun off. Exceptions (off unless hours are given): 2002-02-25, 2002-03-08.

## Resources

| Resource | Group | Rate | Cost per use |
| --- | --- | --- | --- |
| Иванов | Редактор раздела | 6.25 |  |
| Бумага для типографии |  | 15 |  |
| Фотомодель по контракту | Фотомодель |  | 200 |
| Терехов | Оператор печатного аппарата | 2.5 |  |
| Тарарухин | Оператор печатного аппарата | 3.44 |  |
| Борисов | Оператор печатного аппарата | 3.12 |  |
| Семенов | Оператор Mac | 4.69 |  |
| Бурков | Оператор Mac | 3.12 |  |
| Лимонов | Оператор Mac | 5 |  |
| Улендеева | Верстальщик | 4.69 |  |
| Сергеева | Верстальщик | 3.75 |  |
| Жуков | Фотограф | 3.12 |  |
| Еремин | Дизайнер | 7.5 |  |
| Ураганов | Корректор | 3.12 |  |
| Баранов | Корректор | 3.12 |  |
| Козлов | Технический редактор | 5 |  |
| Васин | Технический редактор | 5 |  |
| Уваров | Главный редактор | 12.5 |  |
| Галкина | Отвественный секретарь | 3.12 |  |
| Сидоров | Редактор раздела | 7.5 |  |
| Петров | Редактор раздела | 6.25 |  |
| Краска для вывода пленок |  | 100 |  |
| Фотопленка |  | 1.5 |  |
| Тарасова | Верстальщик | 4.69 |  |

## Schedule

| ID | WBS | Task | Type | Duration | Start | Finish | Predecessors | Total slack | Free slack | Constraint | Resources | Work | Cost |
| --- | --- | --- | --- | --- | --- | --- | --- | --- | --- | --- | --- | --- | --- |
| 1 | МАЙ//001 | **Планирование номера** |  | 11.62d | 2002-01-10 | 2002-01-25 |  | -0.38d | 0d |  |  | 78h | 533.74 |
| 2 | МАЙ//001.A | Сбор предложений от авторов |  | 5d | 2002-01-10 | 2002-01-16 |  | -0.38d | 0d |  | Иванов [25%]; Петров [25%]; Сидоров [25%] | 15h | 100 |
| 3 | МАЙ//001.B | Подготовка плана номера |  | 3d | 2002-01-17 | 2002-01-21 | 2 | -0.38d | 0d |  | Иванов [25%]; Петров [25%]; Сидоров [25%]; Уваров [12.5%] | 19h | 132.5 |
| 4 | МАЙ//001.C | Предварительная редколлегия |  | 3h | 2002-01-22 | 2002-01-22 | 3 | -0.38d | 0d |  | Иванов; Петров; Сидоров; Галкина; Уваров | 15h | 106.87 |
| 5 | МАЙ//001.D | Доработка планов с учетом замечаний |  | 3d | 2002-01-22 | 2002-01-25 | 4 | -0.38d | 0d |  | Иванов [75%]; Петров [75%]; Сидоров [75%] | 18h | 120 |
| 6 | МАЙ//001.E | Редколлегия |  | 4h | 2002-01-25 | 2002-01-25 | 5 | -0.25d | 0d | start no later than 2002-01-25 | Иванов; Петров; Сидоров; Галкина; Уваров | 11h | 74.37 |
| 7 | МАЙ//001.F | План номера утвержден | milestone | 0d | 2002-01-25 | 2002-01-25 | 6FS-1h | -0.12d | 0d |  |  |  |  |
| 8 | МАЙ//002 | **Подготовка материалов** |  | 41d | 2002-01-25 | 2002-03-27 | 7 | 0d |  |  |  | 700.7h | 4,994.34 |
| 9 | МАЙ//002.A | **Подготовка обложки** |  | 36.25d | 2002-02-01 | 2002-03-27 |  | 0d |  |  |  | 87.4h | 548.91 |
| 10 | МАЙ//002.A-a | Отбор модели |  | 2d | 2002-02-01 | 2002-02-05 |  | 0d |  | must start on 2002-02-01 | Еремин [50%] | 8h | 60 |
| 11 | МАЙ//002.A-b | Фотосъемка модели |  | 4d | 2002-02-05 | 2002-02-11 | 10 | 27.5d | 27.25d |  | Жуков [114.3%]; Фотомодель по контракту [57.1%]; Фотопленка [300%] | 41h | 221.91 |
| 12 | МАЙ//002.A-c | Подготовка анонсов материалов номера для обложки |  | 3d | 2002-03-19 | 2002-03-22 | 22FS-5% | 0.25d | 0d |  | Сидоров [70%] | 16.8h | 126 |
| 13 | МАЙ//002.A-d | Передача рекламных анонсов в предыдущий номер | milestone | 1d | 2002-03-05 | 2002-03-06 | 22FS-5% | 29.5d |  |  |  |  |  |
| 14 | МАЙ//002.A-e | Верстка обложки |  | 3d | 2002-03-22 | 2002-03-27 | 12, 11 | 0.25d | 0d |  | Еремин [70%]; Жуков [20%] | 21.6h | 141 |
| 15 | МАЙ//002.A-f | Обложка готова | milestone | 0d | 2002-03-27 | 2002-03-27 | 14 | 0.25d | 0d |  |  |  |  |
| 16 | МАЙ//002.B | **Подготовка текстов** |  | 34.62d | 2002-01-25 | 2002-03-18 |  | 0d |  |  |  | 613.3h | 4,445.43 |
| 17 | МАЙ//002.B-a | Подготовка редакционных заданий |  | 3.25d | 2002-01-25 | 2002-01-30 |  | -0.12d | 0d | start no later than 2002-01-25 | Иванов; Петров; Сидоров; Галкина [160%] | 72.5h | 419.68 |
| 18 | МАЙ//002.B-b | Рассылка заданий авторам |  | 1.38d | 2002-01-30 | 2002-01-31 | 17 | 0.38d | 0d |  | Галкина [33.3%] | 2h | 6.25 |
| 19 | МАЙ//002.B-c | Утверждение заданий авторами |  | 4d | 2002-02-01 | 2002-02-06 | 18 | 0.38d | 0d |  | Галкина [12.5%] | 4h | 12.5 |
| 20 | МАЙ//002.B-d | Статьи в работе у авторов | milestone | 0d | 2002-02-06 | 2002-02-06 | 19 | 0.38d | 0d |  |  |  |  |
| 21 | МАЙ//002.B-e | Статьи поступили в редакцию | milestone | 0d | 2002-02-20 | 2002-02-20 | 20FS+10d | 0.38d | 0d |  |  |  | 1,000 |
| 22 | МАЙ//002.B-f | Редактирование материалов |  | 15d | 2002-02-21 | 2002-03-15 | 21 | 0.38d | 0d |  | Иванов [50%]; Петров [70%]; Сидоров [50%] | 154h | 1,025 |
| 23 | МАЙ//002.B-g | Техническое редактирование |  | 14d | 2002-02-26 | 2002-03-18 | 22SS+2d | 1.62d | 0d |  | Иванов [30%]; Петров [30%]; Сидоров [95%]; Галкина [50%]; Васин; Козлов | 380.8h | 1,982 |
| 24 | МАЙ//002.B-h | Тексты готовы | milestone | 0d | 2002-03-18 | 2002-03-18 | 23 | 22d |  |  |  |  |  |
| 25 | МАЙ//002.C | Подготовка материалов завершена | milestone | 0d | 2002-03-18 | 2002-03-18 | 23 | 22d |  |  |  |  |  |

Notes:
- 2: Text1: Файл предложений в редакционном формате.
- 3: Text1: План номера в формате XLS с названиями статей от редакторов разделов.
- 4: Text1: Предварительный план номиера обсужден.
- 5: Text1: Планы каждого из редакторов разделов доработаны с учетом замечаний.
- 6: Задания на этот номер должны включать темы: / ·летний отдых; / ·фотокамеры; / ·видеокамеры. / Text1: Окончательный план номера согласован с редакторами разделов и главным редактором.
- 13: Шаблон документа для передачи анонсов.

| ID | WBS | Task | Type | Duration | Start | Finish | Predecessors | Total slack | Free slack | Constraint | Resources | Work | Cost |
| --- | --- | --- | --- | --- | --- | --- | --- | --- | --- | --- | --- | --- | --- |
| 26 | МАЙ//003 | **Верстка журнала** |  | 26d | 2002-03-01 | 2002-04-08 |  | 1.62d |  |  |  | 528.4h | 2,346 |
| 27 | МАЙ//003.A | Обработка текста и иллюстраций |  | 14d | 2002-03-01 | 2002-03-21 | 23SS+3d | 1.62d | 0d |  | Тарасова; Улендеева | 224h | 1,050 |
| 28 | МАЙ//003.B | Вычитка |  | 14d | 2002-03-06 | 2002-03-26 | 27SS+3d | 11d | 4d |  | Баранов [50%]; Ураганов [50%] | 112h | 350 |
| 29 | МАЙ//003.C | Сверка |  | 16d | 2002-03-18 | 2002-04-08 | 28SS+3d | 7d |  | start no earlier than 2002-03-18 | Иванов [30%]; Петров [30%]; Сидоров [30%]; Баранов [50%]; Ураганов [50%] | 182.4h | 876 |
| 30 | МАЙ//003.D | Подготовка оглавления |  | 2d | 2002-03-22 | 2002-03-25 | 27 | 1.62d | 1.38d |  | Сидоров [25%] | 4h | 30 |
| 31 | МАЙ//003.E | Окончательная сборка |  | 2d | 2002-03-27 | 2002-03-29 | 30, 15 | 0.25d | 0d |  | Сидоров [62.5%]; Васин [25%] | 6h | 40 |
| 32 | МАЙ//003.F | Номер сверстан | milestone | 0d | 2002-03-29 | 2002-03-29 | 31 | 0.25d | 0d |  |  |  |  |
| 33 | МАЙ//004 | **Предпечатная подготовка** |  | 13.62d | 2002-03-29 | 2002-04-17 | 32 | 0d |  |  |  | 322.4h | 2,553.26 |
| 34 | МАЙ//004.A | Конвертция сверстанного номера в формат Mac |  | 6d | 2002-03-29 | 2002-04-01 |  | 0d |  |  | Лимонов [111.1%]; Бурков [116.7%]; Семенов [76.9%] | 84h | 350 |
| 35 | МАЙ//004.B | Цветоделение |  | 10.38d | 2002-04-01 | 2002-04-10 | 34 | 0d |  |  | Бурков [20%]; Семенов [20%]; Борисов [25%]; Тарарухин [20%]; Терехов [20%]; Бумага для типографии [12.5%] | 56h | 294 |
| 36 | МАЙ//004.C | Коррекция |  | 7d | 2002-04-02 | 2002-04-06 | 35SS+1d | 0d |  |  | Лимонов [25%]; Бурков [25%]; Семенов [25%] | 42h | 179.37 |
| 37 | МАЙ//004.D | Вывод пленок |  | 15.12d | 2002-04-04 | 2002-04-17 | 36SS+2d | 0d |  | finish no later than 2002-04-20 | Лимонов [34.8%]; Бурков [34.8%]; Борисов [41.8%]; Тарарухин [41.8%]; Терехов [41.8%]; Краска для вывода пленок [17.4%] | 140.4h | 1,729.89 |
| 38 | МАЙ//004.E | Номер готов к передаче в типографию | milestone | 0d | 2002-04-17 | 2002-04-17 | 37 | 0d |  |  |  |  |  |
